# mokran

Schedule from MS Project, 2023-10-05 to 2024-04-09, status date 2023-10-18, A marks actual dates.

## Calendars

- Standard: Mon-Thu 08:00-17:00; Fri-Sat off; Sun 08:00-17:00.

## Schedule

| ID | WBS | Task | Type | Duration | Start | Finish | Predecessors | Complete | Remaining | Baseline start | Baseline finish | Baseline duration | Total slack | Constraint |
| --- | --- | --- | --- | --- | --- | --- | --- | --- | --- | --- | --- | --- | --- | --- |
| 1 | 1 | **LAB Equipment-** |  | 150d | 2023-10-05 A | 2024-04-09 |  | 12% | 132.18d | 2023-09-18 | 2024-02-18 | 123d |  |  |
| 2 | 1.1 | START PROJECT | milestone | 0d | 2023-10-05 A | 2023-10-05 A |  | 100% |  | 2023-09-18 | 2023-09-18 | 0d |  | finish no earlier than 2023-10-05 |
| 3 | 1.2 | ADVANCE PAYMENT | milestone | 0d | 2023-10-05 A | 2023-10-05 A |  | 100% |  | 2023-09-18 | 2023-09-18 | 0d |  |  |
| 4 | 1.3 | **Purchase and Supply** |  | 135d | 2023-10-09 A | 2024-03-24 |  | 12% | 118.63d | 2023-09-21 | 2023-11-21 | 48d |  |  |
| 5 | 1.3.1 | **Atomic Absorption** |  | 115d | 2023-10-09 A | 2024-02-28 |  | 9% | 104.4d | 2023-09-21 | 2023-11-21 | 48d |  |  |
| 6 | 1.3.1.1 | PO AAS |  | 7d | 2023-10-09 A | 2023-10-17 A | 3FS+4d | 100% |  | 2023-09-21 | 2023-10-15 | 18d |  |  |
| 7 | 1.3.1.2 | MANUFARURING |  | 90d | 2023-10-17 A | 2024-02-05 | 6 | 4% | 86.12d | 2023-10-15 | 2023-11-21 | 30d | 51d |  |
| 8 | 1.3.1.3 | customs formalities for export | manual | 4d | 2024-02-05 | 2024-02-08 |  |  |  |  |  |  |  |  |
| 9 | 1.3.1.4 | Shipping | manual | 7d | 2024-02-08 | 2024-02-18 |  |  |  |  |  |  |  |  |
| 10 | 1.3.1.5 | customs clearance | manual | 7d | 2024-02-18 | 2024-02-26 |  |  |  |  |  |  |  |  |
| 11 | 1.3.1.6 | delivery to Site | manual | 2d | 2024-02-26 | 2024-02-27 |  |  |  |  |  |  |  |  |
| 12 | 1.3.1.7 | Inspection at Site | manual | 1d | 2024-02-28 | 2024-02-28 |  |  |  |  |  |  |  |  |
| 13 | 1.3.2 | **Gas Chromatograph** |  | 114.62d | 2023-10-09 A | 2024-02-27 |  | 7% | 106.78d | 2023-09-21 | 2023-11-21 | 48d | 33.12d |  |
| 14 | 1.3.2.1 | PO GC |  | 4d | 2023-10-09 A | 2023-10-12 A | 3FS+4d | 100% |  | 2023-09-21 | 2023-10-15 | 18d |  |  |
| 15 | 1.3.2.2 | MANUFACTURING |  | 90d | 2023-10-16 A | 2024-02-04 | 6 | 4% | 86.12d | 2023-10-15 | 2023-11-21 | 30d | 52.12d |  |
| 16 | 1.3.2.3 | customs formalities for export | manual | 4d | 2024-02-04 | 2024-02-07 |  |  |  |  |  |  |  |  |
| 17 | 1.3.2.4 | Shipping | manual | 7d | 2024-02-07 | 2024-02-15 |  |  |  |  |  |  |  |  |
| 18 | 1.3.2.5 | customs clearance | manual | 7d | 2024-02-17 | 2024-02-25 |  |  |  |  |  |  |  |  |
| 19 | 1.3.2.6 | delivery to Site | manual | 2d | 2024-02-25 | 2024-02-26 |  |  |  |  |  |  |  |  |
| 20 | 1.3.2.7 | Inspection at site | manual | 1d | 2024-02-27 | 2024-02-27 |  |  |  |  |  |  |  |  |
| 21 | 1.3.3 | **Carbon Sullfur Analyzer** |  | 130.5d | 2023-10-09 A | 2024-03-18 |  | 21% | 102.51d | 2023-09-21 | 2023-11-21 | 48d |  |  |
| 22 | 1.3.3.1 | PO CS analyzer |  | 25d | 2023-10-09 A | 2023-11-08 | 3FS+4d | 72% | 7d | 2023-09-21 | 2023-10-15 | 18d | 122.75d |  |
| 23 | 1.3.3.2 | MANUFACTURING |  | 60d | 2023-11-13 A | 2024-01-25 | 6 | 6% | 56.12d | 2023-10-15 | 2023-11-21 | 30d | 59.62d |  |
| 24 | 1.3.3.3 | customs formalities for export | manual | 3d | 2024-01-25 | 2024-01-29 |  |  |  |  |  |  |  |  |
| 25 | 1.3.3.4 | Shipping | manual | 4d | 2024-02-29 | 2024-03-05 |  |  |  |  |  |  |  |  |
| 26 | 1.3.3.5 | customs clearance | manual | 7d | 2024-03-06 | 2024-03-14 |  |  |  |  |  |  |  |  |
| 27 | 1.3.3.6 | delivery to Site | manual | 2d | 2024-03-14 | 2024-03-17 |  |  |  |  |  |  |  |  |
| 28 | 1.3.3.7 | Inspection at site | manual | 1d | 2024-03-18 | 2024-03-18 |  |  |  |  |  |  |  |  |

| ID | WBS | Task | Duration | Start | Finish | Baseline start | Baseline finish | Baseline duration | Total slack | Constraint |
| --- | --- | --- | --- | --- | --- | --- | --- | --- | --- | --- |
| 29 | 1.4 | **Final Book** | 7d | 2024-03-20 | 2024-03-28 | 2023-12-31 | 2024-01-17 | 14d | 9.12d |  |
| 30 | 1.4.1 | Final Data Book | 7d | 2024-03-20 | 2024-03-28 | 2023-12-31 | 2024-01-17 | 14d | 9.12d | start no earlier than 2024-03-20 |
